# REPROGRAMACIÓN_

Schedule from MS Project, 2023-01-10 to 2023-07-14, status date 2023-06-28, costs in S, A marks actual dates.

## Calendars

- Estándar: Mon-Fri 09:00-13:00, 15:00-19:00; Sat-Sun off.

## Resources

| Resource | Unit | Rate |
| --- | --- | --- |
| operario |  | 24 |
| peon |  | 17 |
| ladrillo | u | 1 |
| cemento | bls | 24 |
| arena gruesa | m3 | 80 |
| herramientas manuales |  |  |
| andamios |  |  |

## Schedule

| ID | WBS | Task | Type | Duration | Start | Finish | Predecessors | Complete | Remaining | Baseline start | Baseline finish | Baseline duration | Total slack | Constraint | Resources | Work | Actual work | Cost | Baseline cost | Actual cost | Item |
| --- | --- | --- | --- | --- | --- | --- | --- | --- | --- | --- | --- | --- | --- | --- | --- | --- | --- | --- | --- | --- | --- |
| 1 | 1 | **CONSTRUCCION DEL LOCAL PARA EL CENTRO DE ACOPIO DEL ANEXO DE LOS ANGELES** |  | 134d | 2023-01-10 A | 2023-07-14 |  | 96% | 5.8d | 2023-01-10 | 2023-06-14 | 112d | 0d |  |  | 4675h | 1075h | 223,985.84 | 145,016.84 | 143,908.5 |  |
| 2 | 1.1 | INICIO | milestone | 0d | 2023-01-10 A | 2023-01-10 A |  | 100% |  | 2023-01-10 | 2023-01-10 |  |  |  |  |  |  |  |  |  |  |
| 3 | 1.2 | **OBRAS PROVISIONALES, TRABAJOS PRELIMINARES, SEGURIDAD Y SALUD** |  | 49d | 2023-01-10 A | 2023-03-17 |  | 99% | 0d | 2023-01-10 | 2023-01-24 | 11d | 0d |  | operario [500%]; peon [300%]; ladrillo [5501 u]; cemento [86 bls]; arena gruesa [16 m3]; herramientas manuales [0.1%]; andamios [0.1%] | 4675h | 1075h | 174,417 | 95,448 | 95,170 | 1.00 |
| 4 | 1.2.1 | **OBRAS PROVISIONALES, TRABAJOS PRELIMINARES** |  | 49d | 2023-01-10 A | 2023-03-17 |  | 99% | 0d | 2023-01-10 | 2023-01-24 | 11d | 0d |  | operario [200%]; cemento [16 bls] | 971h | 251h | 68,049 | 50,745 | 50,622 | 1.01 |
| 5 | 1.2.1.1 | **CONSTRUCCIONES PROVISIONALES** |  | 2d | 2023-01-10 A | 2023-01-11 A |  | 100% |  | 2023-01-10 | 2023-01-11 | 2d |  |  | peon [300%]; arena gruesa [15 m3] | 45h | 45h | 29,685 | 29,685 | 29,685 | 1.01.01 |
| 6 | 1.2.1.1.1 | ALMACEN DE MATERIALES, CASETA DE VIGILANCIA Y OFICINA |  | 1d | 2023-01-10 A | 2023-01-10 A | 2 | 100% |  | 2023-01-10 | 2023-01-10 | 1d |  |  |  |  |  | 600 | 600 | 600 | 1.01.01.01 |
| 7 | 1.2.1.1.2 | CARTEL DE IDENTIFICACION DE LA OBRA |  | 1d | 2023-01-11 A | 2023-01-11 A | 6 | 100% |  | 2023-01-11 | 2023-01-11 | 1d |  |  |  |  |  | 450 | 450 | 450 | 1.01.01.02 |
| 8 | 1.2.1.2 | **TRABAJOS PRELIMINARES** |  | 46d | 2023-01-13 A | 2023-03-17 A |  | 100% |  | 2023-01-13 | 2023-01-24 | 8d |  |  |  |  |  | 3,456 | 3,456 | 3,456 | 1.01.02 |
| 9 | 1.2.1.2.1 | NIVELACION, TRAZO Y REPLANTEO CON EQUIPO |  | 3d | 2023-01-20 A | 2023-01-24 A | 10 | 100% |  | 2023-01-20 | 2023-01-24 | 3d |  |  |  |  |  | 170.5 | 170.5 | 170.5 | 1.01.02.01 |
| 10 | 1.2.1.2.2 | LIMPIEZA DE TERRENO MANUAL |  | 20d | 2023-01-13 A | 2023-03-17 A | 7, 12 | 100% |  | 2023-01-13 | 2023-01-19 | 5d |  |  |  |  |  | 85.5 | 85.5 | 85.5 | 1.01.02.02 |
| 11 | 1.2.2 | **SEGURIDAD Y SALUD** |  | 1d | 2023-01-12 A | 2023-01-12 A |  | 100% |  | 2023-01-12 | 2023-01-12 | 1d |  |  |  |  |  | 1,150 | 1,150 | 1,150 | 1.02 |
| 12 | 1.2.2.1 | EQUIPOS DE PROTECCION |  | 1d | 2023-01-12 A | 2023-01-12 A | 7 | 100% |  | 2023-01-12 | 2023-01-12 | 1d |  |  |  |  |  | 1,150 | 1,150 | 1,150 | 1.02.01 |
| 13 | 1.3 | **ESTRUCTURAS** |  | 70d | 2023-01-25 A | 2023-05-02 A |  | 100% |  | 2023-01-25 | 2023-04-13 | 57d |  |  |  |  |  | 26,633.57 | 26,633.57 | 26,633.57 | 2.00 |
| 14 | 1.3.1 | **MOVIMIENTO DE TIERRAS** |  | 36d | 2023-01-25 A | 2023-03-15 A |  | 100% |  | 2023-01-25 | 2023-02-24 | 23d |  |  |  |  |  | 1,949.49 | 1,949.49 | 1,949.49 | 2.01 |
| 15 | 1.3.1.1 | EXCAVACION DE ZANJAS PARA ZAPATAS, CIMIENTOS |  | 3d | 2023-01-25 A | 2023-01-27 A | 9 | 100% |  | 2023-01-25 | 2023-01-27 | 3d |  |  |  |  |  | 786 | 786 | 786 | 2.01.01 |
| 16 | 1.3.1.2 | RELLENO COMPACTADO CON MATERIAL PROPIO (con equipo) |  | 3d | 2023-03-09 A | 2023-03-13 A | 21, 26 | 100% |  | 2023-02-20 | 2023-02-22 | 3d |  | start no earlier than 2023-03-07 |  |  |  | 567.92 | 567.92 | 567.92 | 2.01.02 |
| 17 | 1.3.1.3 | ELIMINACION DE MATERIAL EXCEDENTE (equipo distancia = 5 Km) |  | 2d | 2023-03-14 A | 2023-03-15 A | 16 | 100% |  | 2023-02-23 | 2023-02-24 | 2d |  | start no earlier than 2023-03-07 |  |  |  | 595.57 | 595.57 | 595.57 | 2.01.03 |
| 18 | 1.3.2 | **CONCRETO SIMPLE** |  | 67d | 2023-01-30 A | 2023-05-02 A |  | 100% |  | 2023-01-30 | 2023-04-13 | 54d |  |  |  |  |  | 2,406.9 | 2,406.9 | 2,406.9 | 2.02 |
| 19 | 1.3.2.1 | CONCRETO PARA SOLADO e=2" |  | 1d | 2023-01-30 A | 2023-01-30 A | 15 | 100% |  | 2023-01-30 | 2023-01-30 | 1d |  |  |  |  |  | 347.7 | 347.7 | 347.7 | 2.02.01 |
| 20 | 1.3.2.2 | CONCRETO P/CIMIENTOS CORRIDOS MEZ. 1:10 + 30% P.G. CEMENTO TIPO I |  | 2d | 2023-02-08 A | 2023-02-09 A | 19, 26 | 100% |  | 2023-02-08 | 2023-02-09 | 2d |  |  |  |  |  | 758.73 | 758.73 | 758.73 | 2.02.02 |
| 21 | 1.3.2.3 | CONCRETO P/SOBRECIMIENTO CORRIDO C : H 1:8 + 25% P.M. |  | 1d | 2023-03-08 A | 2023-03-08 A | 22 | 100% |  | 2023-02-17 | 2023-02-17 | 1d |  | start no earlier than 2023-03-07 |  |  |  | 329.35 | 329.35 | 329.35 | 2.02.03 |
| 22 | 1.3.2.4 | ENCOFRADO Y DESENCOFRADO NORMAL PARA SOBRECIMIENTOS |  | 5d | 2023-02-10 A | 2023-03-07 A | 20 | 100% |  | 2023-02-10 | 2023-02-16 | 5d |  |  |  |  |  | 290.87 | 290.87 | 290.87 | 2.02.04 |
| 23 | 1.3.2.5 | CONCRETO PARA FALSO PISO DE 4" CON MEZC. 1:8 C:H |  | 2d | 2023-05-01 A | 2023-05-02 A | 43 | 100% |  | 2023-04-12 | 2023-04-13 | 2d |  |  |  |  |  | 680.25 | 680.25 | 680.25 | 2.02.05 |
| 24 | 1.3.3 | **CONCRETO ARMADO** |  | 54d | 2023-01-30 A | 2023-04-13 A |  | 100% |  | 2023-01-30 | 2023-03-27 | 41d |  |  |  |  |  | 22,277.18 | 22,277.18 | 22,277.18 | 2.03 |
| 25 | 1.3.3.1 | **ZAPATAS** |  | 7d | 2023-01-30 A | 2023-02-07 A |  | 100% |  | 2023-01-30 | 2023-02-07 | 7d |  |  |  |  |  | 5,973 | 5,973 | 5,973 | 2.03.01 |
| 26 | 1.3.3.1.1 | CONCRETO f'c 210 kg/cm2 PARA ZAPATAS |  | 3d | 2023-02-03 A | 2023-02-07 A | 27, 19 | 100% |  | 2023-02-03 | 2023-02-07 | 3d |  |  |  |  |  | 4,954.41 | 4,954.41 | 4,954.41 | 2.03.01.01 |
| 27 | 1.3.3.1.2 | ACERO fy=4200 kg/cm2 GRADO 60 PARA ZAPATAS |  | 4d | 2023-01-30 A | 2023-02-02 A | 15 | 100% |  | 2023-01-30 | 2023-02-02 | 4d |  |  |  |  |  | 1,018.59 | 1,018.59 | 1,018.59 | 2.03.01.02 |

| ID | WBS | Task | Duration | Start | Finish | Predecessors | Complete | Baseline start | Baseline finish | Baseline duration | Constraint | Cost | Baseline cost | Actual cost | Item |
| --- | --- | --- | --- | --- | --- | --- | --- | --- | --- | --- | --- | --- | --- | --- | --- |
| 28 | 1.3.3.2 | **COLUMNAS** | 38d | 2023-01-30 A | 2023-03-22 A |  | 100% | 2023-01-30 | 2023-03-03 | 25d |  | 4,887.47 | 4,887.47 | 4,887.47 | 2.03.02 |
| 29 | 1.3.3.2.1 | CONCRETO f'c 210 kg/cm2 PARA COLUMNAS | 2d | 2023-03-20 A | 2023-03-21 A | 30FS-3d | 100% | 2023-03-01 | 2023-03-02 | 2d | start no earlier than 2023-03-07 | 1,506.17 | 1,506.17 | 1,506.17 | 2.03.02.01 |
| 30 | 1.3.3.2.2 | ENCOFRADO Y DESENCOFRADO NORMAL PARA COLUMNAS | 5d | 2023-03-16 A | 2023-03-22 A | 31, 17 | 100% | 2023-02-27 | 2023-03-03 | 5d | start no earlier than 2023-03-07 | 2,745.1 | 2,745.1 | 2,745.1 | 2.03.02.02 |
| 31 | 1.3.3.2.3 | ACERO fy=4200 kg/cm2 GRADO 60 PARA COLUMNAS | 3d | 2023-01-30 A | 2023-02-01 A | 15 | 100% | 2023-01-30 | 2023-02-01 | 3d |  | 636.2 | 636.2 | 636.2 | 2.03.02.03 |
| 32 | 1.3.3.3 | **VIGAS** | 8d | 2023-03-23 A | 2023-04-03 A |  | 100% | 2023-03-06 | 2023-03-15 | 8d |  | 3,746.84 | 3,746.84 | 3,746.84 | 2.03.03 |
| 33 | 1.3.3.3.1 | CONCRETO f'c 210 kg/cm2 PARA VIGAS | 2d | 2023-03-31 A | 2023-04-03 A | 35 | 100% | 2023-03-14 | 2023-03-15 | 2d |  | 1,406.55 | 1,406.55 | 1,406.55 | 2.03.03.01 |
| 34 | 1.3.3.3.2 | ENCOFRADO Y DESENCOFRADO NORMAL PARA VIGAS | 8d | 2023-03-23 A | 2023-04-03 A | 30 | 100% | 2023-03-06 | 2023-03-15 | 8d | start no earlier than 2023-03-07 | 1,817.92 | 1,817.92 | 1,817.92 | 2.03.03.02 |
| 35 | 1.3.3.3.3 | ACERO fy=4200 kg/cm2 GRADO 60 PARA VIGAS | 5d | 2023-03-24 A | 2023-03-30 A | 34SS+1d | 100% | 2023-03-07 | 2023-03-13 | 5d | start no earlier than 2023-03-07 | 522.37 | 522.37 | 522.37 | 2.03.03.03 |
| 36 | 1.3.3.4 | **LOSA ALIGERADA UNA DIRECCION** | 8d | 2023-04-04 A | 2023-04-13 A |  | 100% | 2023-03-16 | 2023-03-27 | 8d |  | 7,669.87 | 7,669.87 | 7,669.87 | 2.03.04 |
| 37 | 1.3.3.4.1 | CONCRETO f'c 210 kg/cm2 PARA LOSAS ALIGERADAS | 2d | 2023-04-12 A | 2023-04-13 A | 40 | 100% | 2023-03-24 | 2023-03-27 | 2d |  | 2,450.16 | 2,450.16 | 2,450.16 | 2.03.04.01 |
| 38 | 1.3.3.4.2 | ENCOFRADO Y DESENCOFRADO NORMAL PARA LOSAS ALIGERADAS | 8d | 2023-04-04 A | 2023-04-13 A | 33, 34 | 100% | 2023-03-16 | 2023-03-27 | 8d |  | 1,818.62 | 1,818.62 | 1,818.62 | 2.03.04.02 |
| 39 | 1.3.3.4.3 | ACERO fy=4200 kg/cm2 GRADO 60 PARA LOSAS ALIGERADAS | 4d | 2023-04-06 A | 2023-04-11 A | 38SS+2d | 100% | 2023-03-20 | 2023-03-23 | 4d |  | 1,557.59 | 1,557.59 | 1,557.59 | 2.03.04.03 |
| 40 | 1.3.3.4.4 | LADRILLO HUECO DE ARCILLA h=15 cm PARA TECHO ALIGERADO | 3d | 2023-04-07 A | 2023-04-11 A | 39SS+1d, 38SS+3d | 100% | 2023-03-21 | 2023-03-23 | 3d |  | 1,843.5 | 1,843.5 | 1,843.5 | 2.03.04.04 |
| 41 | 1.4 | **ARQUITECTURA** | 45d | 2023-04-14 A | 2023-06-15 A |  | 100% | 2023-03-28 | 2023-05-29 | 45d |  | 19,773.06 | 19,773.06 | 19,773.06 | 3.00 |
| 42 | 1.4.1 | **ALBAÑILERIA Y TABIQUERIA LIGERA** | 11d | 2023-04-14 A | 2023-04-28 A |  | 100% | 2023-03-28 | 2023-04-11 | 11d |  | 5,745.26 | 5,745.26 | 5,745.26 | 3.01 |
| 43 | 1.4.1.1 | MURO LADR. K.K. MEZC.C:A 1:4, TIPO IV, P.TARRAJ. DE SOGA | 11d | 2023-04-14 A | 2023-04-28 A | 38 | 100% | 2023-03-28 | 2023-04-11 | 11d |  | 5,745.26 | 5,745.26 | 5,745.26 | 3.01.01 |
| 44 | 1.4.2 | **REVOQUES ENLUCIDOS Y MOLDURAS** | 18d | 2023-05-03 A | 2023-05-26 A |  | 100% | 2023-04-14 | 2023-05-09 | 18d |  | 3,947.44 | 3,947.44 | 3,947.44 | 3.02 |
| 45 | 1.4.2.1 | TARRAJEO EN INT. Y EXT. FROTACHADO CON MEZCLA C:A 1:5 | 10d | 2023-05-11 A | 2023-05-24 A | 23, 51, 47 | 100% | 2023-04-24 | 2023-05-05 | 10d |  | 2,988.38 | 2,988.38 | 2,988.38 | 3.02.01 |
| 46 | 1.4.2.2 | TARRAJEO DE COLUMNAS CON MEZCLA C:A 1:5 | 5d | 2023-05-11 A | 2023-05-17 A | 45SS, 29 | 100% | 2023-04-24 | 2023-04-28 | 5d |  | 372.38 | 372.38 | 372.38 | 3.02.02 |
| 47 | 1.4.2.3 | TARRAJEO EN VIGAS CON MEZCLA C:A 1:5 | 5d | 2023-05-03 A | 2023-05-09 A | 34, 51SS | 100% | 2023-04-14 | 2023-04-20 | 5d |  | 256.24 | 256.24 | 256.24 | 3.02.03 |
| 48 | 1.4.2.4 | VESTIDURAS DE DERRAMES EN PUERTAS, VENTANAS Y VANOS | 2d | 2023-05-25 A | 2023-05-26 A | 45, 46, 47 | 100% | 2023-05-08 | 2023-05-09 | 2d |  | 185.32 | 185.32 | 185.32 | 3.02.04 |
| 49 | 1.4.2.5 | BRUÑAS | 1d | 2023-05-25 A | 2023-05-25 A | 45, 48SS | 100% | 2023-05-08 | 2023-05-08 | 1d |  | 145.12 | 145.12 | 145.12 | 3.02.05 |
| 50 | 1.4.3 | **CIELORASO** | 6d | 2023-05-03 A | 2023-05-10 A |  | 100% | 2023-04-14 | 2023-04-21 | 6d |  | 900.16 | 900.16 | 900.16 | 3.03 |
| 51 | 1.4.3.1 | CIELORASO CON MEZCLA CEMENTO - ARENA 1:5 E= 1.5cm | 6d | 2023-05-03 A | 2023-05-10 A | 37FS+6d, 23 | 100% | 2023-04-14 | 2023-04-21 | 6d |  | 900.16 | 900.16 | 900.16 | 3.03.01 |

| ID | WBS | Task | Duration | Start | Finish | Predecessors | Complete | Remaining | Baseline start | Baseline finish | Baseline duration | Total slack | Free slack | Constraint | Cost | Baseline cost | Actual cost | Item |
| --- | --- | --- | --- | --- | --- | --- | --- | --- | --- | --- | --- | --- | --- | --- | --- | --- | --- | --- |
| 52 | 1.4.4 | **PISOS Y PAVIMENTOS** | 6d | 2023-05-29 A | 2023-06-05 A |  | 100% |  | 2023-05-10 | 2023-05-17 | 6d |  |  |  | 2,967.12 | 2,967.12 | 2,967.12 | 3.04 |
| 53 | 1.4.4.1 | CONTRAPISO e=42mm | 3d | 2023-05-29 A | 2023-05-31 A | 23, 48 | 100% |  | 2023-05-10 | 2023-05-12 | 3d |  |  |  | 1,375.4 | 1,375.4 | 1,375.4 | 3.04.01 |
| 54 | 1.4.4.2 | PISO CERAMICO SERIE AMERICA COLOR BLANCO 30x30cm | 3d | 2023-06-01 A | 2023-06-05 A | 53 | 100% |  | 2023-05-15 | 2023-05-17 | 3d |  |  |  | 1,591.72 | 1,591.72 | 1,591.72 | 3.04.02 |
| 55 | 1.4.5 | **ZOCALOS Y CONTRAZOCALOS** | 6d | 2023-06-06 A | 2023-06-13 A |  | 100% |  | 2023-05-18 | 2023-05-25 | 6d |  |  |  | 643.68 | 643.68 | 643.68 | 3.05 |
| 56 | 1.4.5.1 | ZOCALO DE CERAMICA DE 30x30cm SERIE AMERICA COLOR BLANCO | 4d | 2023-06-06 A | 2023-06-09 A | 54 | 100% |  | 2023-05-18 | 2023-05-23 | 4d |  |  |  | 298.47 | 298.47 | 298.47 | 3.05.01 |
| 57 | 1.4.5.2 | CONTRAZOCALO DE CEMENTO PULIDO H = 30 cm | 2d | 2023-06-12 A | 2023-06-13 A | 56 | 100% |  | 2023-05-24 | 2023-05-25 | 2d |  |  |  | 345.21 | 345.21 | 345.21 | 3.05.02 |
| 58 | 1.4.6 | **CARPINTERIA DE MADERA** | 8d | 2023-05-29 A | 2023-06-07 A |  | 100% |  | 2023-05-10 | 2023-05-19 | 8d |  |  |  | 1,124.35 | 1,124.35 | 1,124.35 | 3.06 |
| 59 | 1.4.6.1 | PUERTA APANELADA DE MADERA (P-01, P-02, P-03, P-04, P-05) | 8d | 2023-05-29 A | 2023-06-07 A | 48 | 100% |  | 2023-05-10 | 2023-05-19 | 8d |  |  |  | 1,124.35 | 1,124.35 | 1,124.35 | 3.06.01 |
| 60 | 1.4.7 | **CARPINTERIA METALICA** | 10d | 2023-05-29 A | 2023-06-09 A |  | 100% |  | 2023-05-10 | 2023-05-23 | 10d |  |  |  | 2,978.14 | 2,978.14 | 2,978.14 | 3.07 |
| 61 | 1.4.7.1 | VENTANAS METALICAS SEGÚN DISEÑO | 10d | 2023-05-29 A | 2023-06-09 A | 48 | 100% |  | 2023-05-10 | 2023-05-23 | 10d |  |  |  | 2,978.14 | 2,978.14 | 2,978.14 | 3.07.01 |
| 62 | 1.4.8 | **VIDRIOS Y SIMILARES** | 3d | 2023-06-12 A | 2023-06-14 A |  | 100% |  | 2023-05-24 | 2023-05-26 | 3d |  |  |  | 435.78 | 435.78 | 435.78 | 3.08 |
| 63 | 1.4.8.1 | VIDRIO INCOLORO CRUDO DE 6mm | 3d | 2023-06-12 A | 2023-06-14 A | 61 | 100% |  | 2023-05-24 | 2023-05-26 | 3d |  |  |  | 435.78 | 435.78 | 435.78 | 3.08.01 |
| 64 | 1.4.9 | **PINTURA** | 14d | 2023-05-29 A | 2023-06-15 A |  | 100% |  | 2023-05-10 | 2023-05-29 | 14d |  |  |  | 1,031.13 | 1,031.13 | 1,031.13 | 3.09 |
| 65 | 1.4.9.1 | PINTURA VINILICA EN MUROS INTERIORES, EXTERIORES Y COLUMNAS | 6d | 2023-05-29 A | 2023-06-05 A | 45, 46, 48 | 100% |  | 2023-05-10 | 2023-05-17 | 6d |  |  |  | 685.45 | 685.45 | 685.45 | 3.09.01 |
| 66 | 1.4.9.2 | PINTURA VINILICA EN CIELO RASOS Y VIGAS 2 MANOS | 2d | 2023-06-14 A | 2023-06-15 A | 51, 47, 57 | 100% |  | 2023-05-26 | 2023-05-29 | 2d |  |  |  | 345.68 | 345.68 | 345.68 | 3.09.02 |
| 67 | 1.5 | **INSTALACIONES SANITARIAS** | 43d | 2023-03-08 A | 2023-05-05 A |  | 100% |  | 2023-02-17 | 2023-04-18 | 43d |  |  |  | 496.62 | 496.62 | 496.62 | 4.00 |
| 68 | 1.5.1 | **SISTEMA DE DRENAJE DE AGUAS PLUVIALES** | 43d | 2023-03-08 A | 2023-05-05 A |  | 100% |  | 2023-02-17 | 2023-04-18 | 43d |  |  |  | 496.62 | 496.62 | 496.62 | 4.01 |
| 69 | 1.5.1.1 | CANALETA DE CONCRETO DRENAJE PLUVIAL | 2d | 2023-05-04 A | 2023-05-05 A | 71, 37, 70 | 100% |  | 2023-04-17 | 2023-04-18 | 2d |  |  |  | 334.22 | 334.22 | 334.22 | 4.01.01 |
| 70 | 1.5.1.2 | MONTANTES DE PVC Ø4" PARA DRENAJE PLUVIAL | 3d | 2023-05-01 A | 2023-05-03 A | 71, 43 | 100% |  | 2023-04-12 | 2023-04-14 | 3d |  |  |  | 73.24 | 73.24 | 73.24 | 4.01.02 |
| 71 | 1.5.1.3 | REDES DE PVC Ø4" PARA DRENAJE PLUVIAL | 1d | 2023-03-08 A | 2023-03-08 A | 22 | 100% |  | 2023-02-17 | 2023-02-17 | 1d |  |  | start no earlier than 2023-03-07 | 89.16 | 89.16 | 89.16 | 4.01.03 |
| 72 | 1.6 | **INSTALACIONES ELECTRICAS** | 21d | 2023-06-16 A | 2023-07-14 |  | 67% | 7d | 2023-05-30 | 2023-06-14 | 12d | 0d |  |  | 2,665.59 | 2,665.59 | 1,835.25 | 5.00 |
| 73 | 1.6.1 | **SALIDAS PARA ALUMBRADO** | 12d | 2023-06-26 A | 2023-07-11 | 86 | 92% | 1d | 2023-06-07 | 2023-06-09 | 3d | 1d |  |  | 130.12 | 130.12 | 119.71 | 5.01 |
| 74 | 1.6.1.1 | SALIDA PARA CENTRO DE LUZ EN TECHO | 3d | 2023-06-26 A | 2023-07-11 |  | 92% | 0.25d | 2023-06-07 | 2023-06-09 | 3d | 1d | 0d |  | 130.12 | 130.12 | 119.71 | 5.01.01 |
| 75 | 1.6.2 | **SALIDAS PARA TOMACORRIENTES** | 13d | 2023-06-28 A | 2023-07-14 |  | 19% | 10.56d | 2023-06-09 | 2023-06-14 | 4d | 0d |  |  | 235.41 | 235.41 | 44.73 | 5.02 |
| 76 | 1.6.2.1 | TOMACORRIENTE DOBLE T/ BIPOLAR | 4d | 2023-06-28 A | 2023-07-14 | 87SS | 19% | 3.25d | 2023-06-09 | 2023-06-14 | 4d | 0d |  |  | 235.41 | 235.41 | 44.73 | 5.02.01 |

| ID | WBS | Task | Type | Duration | Start | Finish | Predecessors | Complete | Remaining | Baseline start | Baseline finish | Baseline duration | Total slack | Free slack | Constraint | Cost | Baseline cost | Actual cost | Item |
| --- | --- | --- | --- | --- | --- | --- | --- | --- | --- | --- | --- | --- | --- | --- | --- | --- | --- | --- | --- |
| 77 | 1.6.3 | **SALIDAS PARA INTERRUPTORES** |  | 2d | 2023-06-26 A | 2023-06-27 A |  | 100% |  | 2023-06-07 | 2023-06-08 | 2d |  |  |  | 309.54 | 309.54 | 309.54 | 5.03 |
| 78 | 1.6.3.1 | SALIDA PARA INTERRUPTOR UNIPOLAR SIMPLE |  | 2d | 2023-06-26 A | 2023-06-27 A | 86 | 100% |  | 2023-06-07 | 2023-06-08 | 2d |  |  |  | 188.24 | 188.24 | 188.24 | 5.03.01 |
| 79 | 1.6.3.2 | SALIDA PARA INTERRUPTOR UNIPOLAR DOBLE |  | 2d | 2023-06-26 A | 2023-06-27 A | 86 | 100% |  | 2023-06-07 | 2023-06-08 | 2d |  |  |  | 121.3 | 121.3 | 121.3 | 5.03.02 |
| 80 | 1.6.4 | **TABLEROS** |  | 2d | 2023-06-26 A | 2023-06-27 A |  | 100% |  | 2023-06-07 | 2023-06-08 | 2d |  |  |  | 320.77 | 320.77 | 320.77 | 5.04 |
| 81 | 1.6.4.1 | TABLERO GENERAL TG |  | 1d | 2023-06-26 A | 2023-06-26 A | 74SS | 100% |  | 2023-06-07 | 2023-06-07 | 1d |  |  |  | 188.32 | 188.32 | 188.32 | 5.04.01 |
| 82 | 1.6.4.2 | TABLERO DE DISTRIBUCION TD |  | 2d | 2023-06-26 A | 2023-06-27 A | 74SS | 100% |  | 2023-06-07 | 2023-06-08 | 2d |  |  |  | 132.45 | 132.45 | 132.45 | 5.04.02 |
| 83 | 1.6.5 | **ALIMENTADORES Y CONDUCTORES** |  | 19d | 2023-06-16 A | 2023-07-12 |  | 83% | 3.17d | 2023-05-30 | 2023-06-12 | 10d | 2d |  |  | 1,283.55 | 1,283.55 | 1,040.5 | 5.05 |
| 84 | 1.6.5.1 | ALIMENTADOR 2-1x10 mm2 - 25mmPVC-P |  | 1d | 2023-06-16 A | 2023-06-16 A | 66, 65 | 100% |  | 2023-05-30 | 2023-05-30 | 1d |  |  |  | 276.2 | 276.2 | 276.2 | 5.05.01 |
| 85 | 1.6.5.2 | ALIMENTADOR 2-1x6 mm2 + 1x6mm2(T) - 25mmPVC-P |  | 1d | 2023-06-19 A | 2023-06-19 A | 84 | 100% |  | 2023-05-31 | 2023-05-31 | 1d |  |  |  | 247.8 | 247.8 | 247.8 | 5.05.02 |
| 86 | 1.6.5.3 | CONDUCTOR 2-1x2.5mm2 - 20mmPVC-P |  | 4d | 2023-06-20 A | 2023-06-23 A | 85 | 100% |  | 2023-06-01 | 2023-06-06 | 4d |  |  |  | 258.23 | 258.23 | 258.23 | 5.05.03 |
| 87 | 1.6.5.4 | CONDUCTOR 2-1x4mm2 + 1x4mm2(N) - 20mmPVC-P |  | 2d | 2023-06-28 A | 2023-07-12 | 82 | 38% | 1.25d | 2023-06-09 | 2023-06-12 | 2d | 2d | 0d |  | 318.16 | 318.16 | 120.9 | 5.05.04 |
| 88 | 1.6.5.5 | CONDUCTOR DE CU DESNUDO 1x10mm2 - 25mmØ PVC-P |  | 1d | 2023-06-28 A | 2023-07-11 | 81, 82 | 75% | 0.25d | 2023-06-09 | 2023-06-09 | 1d | 3d |  |  | 183.16 | 183.16 | 137.37 | 5.05.05 |
| 89 | 1.6.6 | **ARTEFACTOS DE ALUMBRADO** |  | 2d | 2023-07-12 | 2023-07-13 |  |  |  | 2023-06-12 | 2023-06-13 | 2d | 1d |  |  | 386.2 | 386.2 |  | 5.06 |
| 90 | 1.6.6.1 | ARTEFACTO FLOURESCENTE CIRCULAR 1x32W, INC. EQUIPO Y PANTALLA |  | 2d | 2023-07-12 | 2023-07-13 | 74 |  |  | 2023-06-12 | 2023-06-13 | 2d | 1d |  | start no earlier than 2023-07-11 | 272.8 | 272.8 |  | 5.06.01 |
| 91 | 1.6.6.2 | ARTEFACTO TIPO SPOT LIGHT, INC. EQUIPO COMPLETO |  | 2d | 2023-07-12 | 2023-07-13 | 74 |  |  | 2023-06-12 | 2023-06-13 | 2d | 1d |  | start no earlier than 2023-07-11 | 113.4 | 113.4 |  | 5.06.02 |
| 92 | 1.7 | FIN | milestone | 0d | 2023-07-14 | 2023-07-14 | 76 |  |  | 2023-06-14 | 2023-06-14 |  | 0d |  | start no earlier than 2023-07-11 |  |  |  |  |
